Schedule from MS Project, 2004-02-10 to 2004-05-05.
*

## Calendars

- 标准: Mon-Fri 08:00-12:00, 13:00-17:00; Sat-Sun off. Exceptions (off unless hours are given): 2004-02-01 to 2004-06-30 08:00-12:00, 13:00-17:00.

## Schedule

| ID | Task | Duration | Start | Finish | Total slack | Constraint |
| --- | --- | --- | --- | --- | --- | --- |
| 1 | 污水管线 | 5d | 2004-02-16 | 2004-02-20 | 75d | finish no earlier than 2004-02-20 |
| 2 | 隔油池 | 13d | 2004-02-27 | 2004-03-10 | 56d | finish no earlier than 2004-03-10 |
| 3 | 电力沟 | 25d | 2004-02-10 | 2004-03-05 | 61d | finish no earlier than 2004-03-05 |
| 4 | 北侧直埋电力管线 | 15d | 2004-03-06 | 2004-03-20 | 46d | finish no earlier than 2004-03-20 |
| 5 | 上水管线 | 7d | 2004-03-14 | 2004-03-20 | 46d | finish no earlier than 2004-03-20 |
| 6 | 东北侧道路外弃土 | 9d | 2004-03-17 | 2004-03-25 | 41d | finish no earlier than 2004-03-25 |
| 7 | 东北侧道路基层混合料 | 6d | 2004-03-29 | 2004-04-03 | 32d | finish no earlier than 2004-04-03 |
| 8 | 东北侧道路道牙安装 | 8d | 2004-04-07 | 2004-04-14 | 21d | finish no earlier than 2004-04-14 |
| 9 | 东北侧道路8cm沥青碎石 | 2d | 2004-04-16 | 2004-04-17 | 18d | finish no earlier than 2004-04-17 |
| 10 | 东北侧道路5cm沥青面层 | 1d | 2004-04-18 | 2004-04-18 | 17d | start no earlier than 2004-04-18 |
| 11 | 西侧雨水 | 11d | 2004-03-26 | 2004-04-05 | 30d | finish no earlier than 2004-04-05 |
| 12 | 西侧直埋电力 | 19d | 2004-03-28 | 2004-04-15 | 20d | finish no earlier than 2004-04-15 |
| 13 | 西侧道路外弃土 | 3d | 2004-04-18 | 2004-04-20 | 15d | finish no earlier than 2004-04-20 |
| 14 | 西侧道路基层混合料 | 2d | 2004-04-24 | 2004-04-25 | 10d | finish no earlier than 2004-04-25 |
| 15 | 西侧道路道牙安装 | 6d | 2004-04-25 | 2004-04-30 | 5d | finish no earlier than 2004-04-30 |
| 16 | 西侧道路沥青面层 | 5d | 2004-05-01 | 2004-05-05 | 0d | finish no earlier than 2004-05-05 |
